# Diseño de una PMO en la empresa JAIME PARRA Y CIA S.A.S

Schedule from MS Project, 2021-04-05 to 2022-05-09, status date 2022-03-13, costs in $, A marks actual dates.
Hewlett-Packard Company

## Calendars

- Estándar: Mon-Fri 08:00-13:00, 14:00-17:00; Sat-Sun off. Exceptions (off unless hours are given): 2021-05-17, 2021-06-07, 2021-06-14, 2021-07-05, 2021-07-20, 2021-08-16, 2021-10-18, 2021-11-01, 2021-11-15, 2021-12-08, 2022-01-10, 2022-03-21, 2022-04-14 to 2022-04-15.

## Resources

| Resource | Unit | Rate |
| --- | --- | --- |
| HERNÁN GUZMÁN |  | 17000 |
| CARLOS GÓMEZ |  | 17000 |
| OSCAR TORRES |  | 17000 |
| CATALINA HERNÁNDEZ |  | 17000 |
| PAPELERÍA | Suministros varios de papelería | 250000 |
| INTERNET | Auxilio de internet | 2000 |

## Schedule

| ID | WBS | Task | Duration | Start | Finish | Predecessors | Complete | Remaining | Baseline start | Baseline finish | Baseline duration | Total slack | Free slack | Resources | Work | Actual work | Cost | Baseline cost | Actual cost | Aceptación de entregable (Texto1) | % Aceptación de entregable | % Satosfacción del cliente |
| --- | --- | --- | --- | --- | --- | --- | --- | --- | --- | --- | --- | --- | --- | --- | --- | --- | --- | --- | --- | --- | --- | --- |
| 1 | 1 | **Diseño de una PMO en la empresa JAIME PARRA Y CIA S.A.S** | 272d | 2021-04-05 A | 2022-05-09 |  | 82% | 48d | 2021-04-05 | 2022-05-09 | 272d | 0d |  |  | 2328h | 1917.2h | 53,690,000 | 54,122,000 | 46,801,782.86 | Aceptable | 88% | 88% |
| 2 | 1.1 | **Planeación del proyecto** | 105d | 2021-04-05 A | 2021-09-06 A |  | 100% |  | 2021-04-05 | 2021-09-06 | 105d |  |  |  | 960h | 960h | 16,846,000 | 17,582,000 | 16,846,000 | Aceptable | 88% | 88% |
| 3 | 1.1.1 | **Acta de constitución del proyecto** | 36d | 2021-04-05 A | 2021-05-25 A |  | 100% |  | 2021-04-05 | 2021-05-25 | 36d |  |  |  | 288h | 288h | 6,146,000 | 6,146,000 | 6,146,000 | Aceptable | 88% | 88% |
| 4 | 1.1.1.1 | Recopilar información existente de la organización | 14d | 2021-04-05 A | 2021-04-22 A |  | 100% |  | 2021-04-05 | 2021-04-22 | 14d |  |  | CARLOS GÓMEZ [25%]; CATALINA HERNÁNDEZ [25%]; HERNÁN GUZMÁN [25%]; OSCAR TORRES [25%]; PAPELERÍA [1 Suministros varios de papelería] | 112h | 112h | 2,154,000 | 2,154,000 | 2,154,000 | Aceptable | 88% | 88% |
| 5 | 1.1.1.2 | Desarrollar el documento que constituya el inicio del proyecto | 21d | 2021-04-23 A | 2021-05-24 A | 4 | 100% |  | 2021-04-23 | 2021-05-24 | 21d |  |  | OSCAR TORRES [25%]; CARLOS GÓMEZ [25%]; CATALINA HERNÁNDEZ [25%]; HERNÁN GUZMÁN [25%]; PAPELERÍA [4 Suministros varios de papelería] | 168h | 168h | 3,856,000 | 3,856,000 | 3,856,000 | Aceptable | 88% | 88% |
| 6 | 1.1.1.3 | Firmar el acta de constitución del proyecto | 1d | 2021-05-25 A | 2021-05-25 A | 4, 5 | 100% |  | 2021-05-25 | 2021-05-25 | 1d |  |  | CARLOS GÓMEZ [25%]; CATALINA HERNÁNDEZ [25%]; HERNÁN GUZMÁN [25%]; OSCAR TORRES [25%] | 8h | 8h | 136,000 | 136,000 | 136,000 | Aceptable | 88% | 88% |
| 7 | 1.1.2 | **Evaluación del plan estratégico de la empresa** | 35d | 2021-05-25 A | 2021-07-16 A |  | 100% |  | 2021-05-25 | 2021-07-16 | 35d |  |  |  | 280h | 280h | 4,800,000 | 4,760,000 | 4,800,000 | Aceptable | 88% | 88% |
| 8 | 1.1.2.1 | Examinar las principales características y variables de la organización mediante el juicio de expertos | 14d | 2021-05-25 A | 2021-06-16 A | 6 | 100% |  | 2021-05-25 | 2021-06-16 | 14d |  |  | CARLOS GÓMEZ [25%]; CATALINA HERNÁNDEZ [25%]; HERNÁN GUZMÁN [25%]; INTERNET; OSCAR TORRES [25%] | 112h | 112h | 1,800,000 | 1,904,000 | 1,800,000 | Aceptable | 88% | 88% |
| 9 | 1.1.2.2 | Realizar el estudio de prefactibilidad del proyecto | 21d | 2021-06-17 A | 2021-07-16 A | 6, 8 | 100% |  | 2021-06-17 | 2021-07-16 | 21d |  |  | CARLOS GÓMEZ [25%]; CATALINA HERNÁNDEZ [25%]; HERNÁN GUZMÁN [25%]; OSCAR TORRES [25%] | 168h | 168h | 3,000,000 | 2,856,000 | 3,000,000 | Aceptable | 88% | 88% |
| 10 | 1.1.3 | **Control y seguimiento** | 15d | 2021-07-19 A | 2021-08-09 A |  | 100% |  | 2021-07-19 | 2021-08-09 | 15d |  |  |  | 120h | 120h | 1,650,000 | 2,044,000 | 1,650,000 | Aceptable | 88% | 88% |
| 11 | 1.1.3.1 | Desarrollar metodologías para el control y siguimiento del proyecto | 7d | 2021-07-19 A | 2021-07-28 A | 9 | 100% |  | 2021-07-19 | 2021-07-28 | 7d |  |  | CARLOS GÓMEZ [25%]; CATALINA HERNÁNDEZ [25%]; HERNÁN GUZMÁN [25%]; INTERNET [1 Auxilio de internet]; OSCAR TORRES [25%] | 56h | 56h | 850,000 | 954,000 | 850,000 | Aceptable | 88% | 88% |
| 12 | 1.1.3.2 | Realizar formatos para auditorias de control y seguimiento | 8d | 2021-07-29 A | 2021-08-09 A | 11 | 100% |  | 2021-07-29 | 2021-08-09 | 8d |  |  | OSCAR TORRES [50%]; CATALINA HERNÁNDEZ [50%]; INTERNET [1 Auxilio de internet] | 64h | 64h | 800,000 | 1,090,000 | 800,000 | Aceptable | 88% | 88% |
| 13 | 1.1.4 | **Análisis de metodologías y estrategias existentes** | 22d | 2021-07-19 A | 2021-08-19 A |  | 100% |  | 2021-07-19 | 2021-08-19 | 22d |  |  |  | 176h | 176h | 3,150,000 | 2,996,000 | 3,150,000 | Aceptable | 88% | 88% |
| 14 | 1.1.4.1 | Realizar una investigación de las metodologías que actualmente se llevan a cabo en la organización | 21d | 2021-07-19 A | 2021-08-18 A | 9 | 100% |  | 2021-07-19 | 2021-08-18 | 21d |  |  | CARLOS GÓMEZ [25%]; CATALINA HERNÁNDEZ [25%]; HERNÁN GUZMÁN [25%]; INTERNET [1 Auxilio de internet]; OSCAR TORRES [25%] | 168h | 168h | 3,000,000 | 2,858,000 | 3,000,000 | Aceptable | 88% | 88% |
| 15 | 1.1.4.2 | Desarrollar entrevista con la alta gerencia de la empresa. | 1d | 2021-08-19 A | 2021-08-19 A | 14 | 100% |  | 2021-08-19 | 2021-08-19 | 1d |  |  | HERNÁN GUZMÁN [50%]; OSCAR TORRES [50%]; INTERNET [1 Auxilio de internet] | 8h | 8h | 150,000 | 138,000 | 150,000 | Aceptable | 88% | 88% |
| 16 | 1.1.5 | **Roles y funciones** | 12d | 2021-08-20 A | 2021-09-06 A |  | 100% |  | 2021-08-20 | 2021-09-06 | 12d |  |  |  | 96h | 96h | 1,100,000 | 1,636,000 | 1,100,000 | Aceptable | 88% | 88% |
| 17 | 1.1.5.1 | Documentar los roles necesarios para conformar la PMO | 7d | 2021-08-20 A | 2021-08-30 A | 12, 15 | 100% |  | 2021-08-20 | 2021-08-30 | 7d |  |  | CARLOS GÓMEZ [50%]; CATALINA HERNÁNDEZ [50%]; INTERNET [1 Auxilio de internet] | 56h | 56h | 600,000 | 954,000 | 600,000 | Aceptable | 88% | 88% |
| 18 | 1.1.5.2 | Establecer las funciones necesarias para conformar la PMO | 5d | 2021-08-31 A | 2021-09-06 A | 17 | 100% |  | 2021-08-31 | 2021-09-06 | 5d |  |  | CARLOS GÓMEZ [50%]; CATALINA HERNÁNDEZ [50%]; INTERNET [1 Auxilio de internet] | 40h | 40h | 500,000 | 682,000 | 500,000 | Aceptable | 88% | 88% |
| 19 | 1.2 | **Modelo de Madurez de la empresa** | 52d | 2021-09-07 A | 2021-11-22 |  | 95% | 2.6d | 2021-09-07 | 2021-11-22 | 52d | 6.3d |  |  | 416h | 395.2h | 7,496,000 | 7,080,000 | 7,121,200 | Aceptable | 88% | 88% |
| 20 | 1.2.1 | **Metodologías de determinación de niveles de madurez** | 22d | 2021-09-07 A | 2021-10-06 |  | 95% | 1.1d | 2021-09-07 | 2021-10-06 | 22d | 9.5d |  |  | 176h | 167.2h | 2,996,000 | 2,996,000 | 2,846,200 | Aceptable | 88% | 88% |
| 21 | 1.2.1.1 | Realizar revisión documental y bibliográfica en metodologías para estimacion de nivel de madurez | 7d | 2021-09-07 A | 2021-09-15 | 18 | 95% | 0.35d | 2021-09-07 | 2021-09-15 | 7d | 14.25d | 0d | CARLOS GÓMEZ [25%]; CATALINA HERNÁNDEZ [25%]; HERNÁN GUZMÁN [25%]; INTERNET [1 Auxilio de internet]; OSCAR TORRES [25%] | 56h | 53.2h | 954,000 | 954,000 | 906,300 | Aceptable | 88% | 88% |
| 22 | 1.2.1.2 | Dimensionar el modelo | 15d | 2021-09-16 A | 2021-10-06 | 21 | 95% | 0.75d | 2021-09-16 | 2021-10-06 | 15d | 9.5d | 0d | CARLOS GÓMEZ [25%]; CATALINA HERNÁNDEZ [25%]; HERNÁN GUZMÁN [25%]; INTERNET [1 Auxilio de internet]; OSCAR TORRES [25%] | 120h | 114h | 2,042,000 | 2,042,000 | 1,939,900 | Aceptable | 88% | 88% |
| 23 | 1.2.2 | **Evaluación y determinación del nivel de madurez organizacional** | 30d | 2021-10-07 A | 2021-11-22 |  | 95% | 1.5d | 2021-10-07 | 2021-11-22 | 30d | 6.3d |  |  | 240h | 228h | 4,500,000 | 4,084,000 | 4,275,000 | Aceptable | 88% | 88% |
| 24 | 1.2.2.1 | Establecer sistemas de medición | 10d | 2021-10-07 A | 2021-10-21 | 21, 22 | 95% | 0.5d | 2021-10-07 | 2021-10-21 | 10d | 19d | 0d | CARLOS GÓMEZ [25%]; CATALINA HERNÁNDEZ [25%]; HERNÁN GUZMÁN [25%]; INTERNET [1 Auxilio de internet]; OSCAR TORRES [25%] | 80h | 76h | 1,500,000 | 1,362,000 | 1,425,000 | Aceptable | 88% | 88% |
| 25 | 1.2.2.2 | Determinar el grado de madurez. | 20d | 2021-10-22 A | 2021-11-22 | 24 | 95% | 1d | 2021-10-22 | 2021-11-22 | 20d | 6.3d | 0d | CARLOS GÓMEZ [25%]; CATALINA HERNÁNDEZ [25%]; HERNÁN GUZMÁN [25%]; INTERNET [1 Auxilio de internet]; OSCAR TORRES [25%] | 160h | 152h | 3,000,000 | 2,722,000 | 2,850,000 | Aceptable | 88% | 88% |

| ID | WBS | Task | Type | Duration | Start | Finish | Predecessors | Complete | Remaining | Baseline start | Baseline finish | Baseline duration | Total slack | Free slack | Resources | Work | Actual work | Cost | Baseline cost | Actual cost | Aceptación de entregable (Texto1) | % Aceptación de entregable | % Satosfacción del cliente |
| --- | --- | --- | --- | --- | --- | --- | --- | --- | --- | --- | --- | --- | --- | --- | --- | --- | --- | --- | --- | --- | --- | --- | --- |
| 26 | 1.3 | **Definición del tipo de PMO** |  | 30d | 2021-11-23 A | 2022-01-04 |  | 88% | 3.75d | 2021-11-23 | 2022-01-04 | 30d | 11.2d |  |  | 240h | 210h | 4,950,000 | 4,088,000 | 4,337,500 | Aceptable | 88% | 88% |
| 27 | 1.3.1 | **Determinación de la PMO del proyecto** |  | 15d | 2021-11-23 A | 2021-12-14 |  | 90% | 1.5d | 2021-11-23 | 2021-12-14 | 15d | 11.9d |  |  | 120h | 108h | 2,600,000 | 2,044,000 | 2,340,000 | Aceptable | 88% | 88% |
| 28 | 1.3.1.1 | Realizar revisión documental y bibliográfica para definir tipos de PMO |  | 7d | 2021-11-23 A | 2021-12-01 | 25 | 90% | 0.7d | 2021-11-23 | 2021-12-01 | 7d | 2.7d | 0d | CARLOS GÓMEZ [25%]; CATALINA HERNÁNDEZ [25%]; HERNÁN GUZMÁN [25%]; INTERNET [1 Auxilio de internet]; OSCAR TORRES [25%] | 56h | 50.4h | 1,000,000 | 954,000 | 900,000 | Aceptable | 88% | 88% |
| 29 | 1.3.1.2 | Identificar el tipo de PMO que mejor se ajuste a la organización |  | 3d | 2021-12-02 A | 2021-12-06 | 28 | 90% | 0.3d | 2021-12-02 | 2021-12-06 | 3d | 4.5d | 0d | CARLOS GÓMEZ [25%]; CATALINA HERNÁNDEZ [25%]; HERNÁN GUZMÁN [25%]; INTERNET [1 Auxilio de internet]; OSCAR TORRES [25%] | 24h | 21.6h | 800,000 | 410,000 | 720,000 | Aceptable | 88% | 88% |
| 30 | 1.3.1.3 | Seleccionar el tipo de PMO a diseñar. |  | 5d | 2021-12-07 A | 2021-12-14 | 28, 29 | 90% | 0.5d | 2021-12-07 | 2021-12-14 | 5d | 11.9d | 0d | CARLOS GÓMEZ [25%]; CATALINA HERNÁNDEZ [25%]; HERNÁN GUZMÁN [25%]; OSCAR TORRES [25%] | 40h | 36h | 800,000 | 680,000 | 720,000 | Aceptable | 88% | 88% |
| 31 | 1.3.2 | **Plan estratégico de la PMO** |  | 15d | 2021-12-15 A | 2022-01-04 |  | 85% | 2.25d | 2021-12-15 | 2022-01-04 | 15d | 11.2d |  |  | 120h | 102h | 2,350,000 | 2,044,000 | 1,997,500 | No aceptable | 88% | 88% |
| 32 | 1.3.2.1 | Formular el documento de estrategia para el diseño de la PMO |  | 14d | 2021-12-15 A | 2022-01-03 | 30 | 85% | 2.1d | 2021-12-15 | 2022-01-03 | 14d | 0.85d | 0d | CARLOS GÓMEZ [25%]; CATALINA HERNÁNDEZ [25%]; HERNÁN GUZMÁN [25%]; OSCAR TORRES [25%]; INTERNET [1 Auxilio de internet] | 112h | 95.2h | 2,000,000 | 1,906,000 | 1,700,000 | No aceptable | 88% | 88% |
| 33 | 1.3.2.2 | Presentar el documento de estrategia a la alta gerencia de la organización para su respectiva aprobación. |  | 1d | 2022-01-04 A | 2022-01-04 | 32 | 85% | 0.15d | 2022-01-04 | 2022-01-04 | 1d | 11.2d | 0d | CATALINA HERNÁNDEZ [25%]; CARLOS GÓMEZ [25%]; HERNÁN GUZMÁN [25%]; INTERNET [1 Auxilio de internet]; OSCAR TORRES [25%] | 8h | 6.8h | 350,000 | 138,000 | 297,500 | No aceptable | 88% | 88% |
| 34 | 1.4 | **Plan de gestión de proyectos** |  | 85d | 2022-01-05 A | 2022-05-09 |  | 49% | 42.98d | 2022-01-05 | 2022-05-09 | 85d | 0d |  |  | 712h | 352h | 11,398,000 | 12,372,000 | 5,497,082.86 | No aceptable | 88% | 88% |
| 35 | 1.4.1 | **Estandarización de procesos** |  | 35d | 2022-01-05 A | 2022-02-23 |  | 80% | 7d | 2022-01-05 | 2022-02-23 | 35d | 12d |  |  | 280h | 224h | 4,400,000 | 5,016,000 | 3,520,000 | No aceptable | 88% | 88% |
| 36 | 1.4.1.1 | Realizar un mapeo de procesos de la organización |  | 14d | 2022-01-05 A | 2022-01-25 | 33 | 80% | 2.8d | 2022-01-05 | 2022-01-25 | 14d | 5.6d | 0d | CARLOS GÓMEZ [50%]; CATALINA HERNÁNDEZ [50%]; INTERNET [1 Auxilio de internet] | 112h | 89.6h | 1,600,000 | 1,906,000 | 1,280,000 | Aceptable | 88% | 88% |
| 37 | 1.4.1.2 | Recopilar documentación de procesos |  | 7d | 2022-01-26 A | 2022-02-03 | 33, 36 | 80% | 1.4d | 2022-01-26 | 2022-02-03 | 7d | 11.2d | 0d | CARLOS GÓMEZ [25%]; CATALINA HERNÁNDEZ [25%]; HERNÁN GUZMÁN [25%]; INTERNET [1 Auxilio de internet]; OSCAR TORRES [25%]; PAPELERÍA [1 Suministros varios de papelería] | 56h | 44.8h | 800,000 | 1,204,000 | 640,000 | No aceptable | 88% | 88% |
| 38 | 1.4.1.3 | Establecer formatos en las áreas que involucran los proyectos de la empresa JAIME PARRA y CIA SAS |  | 14d | 2022-02-04 A | 2022-02-23 | 37 | 80% | 2.8d | 2022-02-04 | 2022-02-23 | 14d | 12d | 0d | CARLOS GÓMEZ [25%]; CATALINA HERNÁNDEZ [25%]; HERNÁN GUZMÁN [25%]; INTERNET [1 Auxilio de internet]; OSCAR TORRES [25%] | 112h | 89.6h | 2,000,000 | 1,906,000 | 1,600,000 | No aceptable | 88% | 88% |
| 39 | 1.4.2 | **Plan de capacitaciones** |  | 35d | 2022-02-24 A | 2022-04-18 |  | 34% | 23d | 2022-02-24 | 2022-04-18 | 35d | 0d |  |  | 280h | 96h | 4,406,000 | 4,764,000 | 1,429,082.86 | No aceptable | 88% | 88% |
| 40 | 1.4.2.1 | Definir capacitaciones inductivas, preventivas, correctivas |  | 21d | 2022-02-24 A | 2022-03-25 | 38 | 57% | 9d | 2022-02-24 | 2022-03-25 | 21d | 0d |  | CARLOS GÓMEZ [25%]; CATALINA HERNÁNDEZ [25%]; HERNÁN GUZMÁN [25%]; OSCAR TORRES [25%]; INTERNET [1 Auxilio de internet] | 168h | 96h | 2,500,000 | 2,858,000 | 1,429,082.86 | No aceptable | 88% | 88% |
| 41 | 1.4.2.2 | Desarrollar el cronograma de capacitación de personal |  | 14d | 2022-03-28 | 2022-04-18 | 40 |  |  | 2022-03-28 | 2022-04-18 | 14d | 0d |  | HERNÁN GUZMÁN [50%]; OSCAR TORRES [50%]; INTERNET [1 Auxilio de internet] | 112h |  | 1,906,000 | 1,906,000 |  | No aceptable | 88% | 88% |
| 42 | 1.4.3 | **Organigrama** |  | 4d | 2022-02-24 A | 2022-03-01 A |  | 100% |  | 2022-02-24 | 2022-03-01 | 4d |  |  |  | 32h | 32h | 548,000 | 548,000 | 548,000 | No aceptable | 88% | 88% |
| 43 | 1.4.3.1 | Incluir la PMO dentro del organigrama de la empresa |  | 3d | 2022-02-24 A | 2022-02-28 A | 38 | 100% |  | 2022-02-24 | 2022-02-28 | 3d |  |  | CARLOS GÓMEZ [25%]; CATALINA HERNÁNDEZ [25%]; HERNÁN GUZMÁN [25%]; INTERNET [1 Auxilio de internet]; OSCAR TORRES [25%] | 24h | 24h | 410,000 | 410,000 | 410,000 | No aceptable | 88% | 88% |
| 44 | 1.4.3.2 | Proponer el organigrama actualizado de la empresa JAIME PARRA y CIA SAS |  | 1d | 2022-03-01 A | 2022-03-01 A | 43 | 100% |  | 2022-03-01 | 2022-03-01 | 1d |  |  | CARLOS GÓMEZ [25%]; CATALINA HERNÁNDEZ [25%]; HERNÁN GUZMÁN [25%]; OSCAR TORRES [25%]; INTERNET [1 Auxilio de internet] | 8h | 8h | 138,000 | 138,000 | 138,000 | No aceptable | 88% | 88% |
| 45 | 1.4.4 | **Cierre** |  | 15d | 2022-04-19 | 2022-05-09 |  |  |  | 2022-04-19 | 2022-05-09 | 15d | 0d |  |  | 120h |  | 2,044,000 | 2,044,000 |  | No aceptable | 88% | 88% |
| 46 | 1.4.4.1 | Elaborar informe de cierre de proyecto |  | 14d | 2022-04-19 | 2022-05-06 | 41, 44 |  |  | 2022-04-19 | 2022-05-06 | 14d | 0d |  | CATALINA HERNÁNDEZ [50%]; CARLOS GÓMEZ [50%]; INTERNET [1 Auxilio de internet] | 112h |  | 1,906,000 | 1,906,000 |  | No aceptable | 88% | 88% |
| 47 | 1.4.4.2 | Presentar el documento de diseño de la PMO a la alta gerencia |  | 1d | 2022-05-09 | 2022-05-09 | 46 |  |  | 2022-05-09 | 2022-05-09 | 1d | 0d |  | CARLOS GÓMEZ [25%]; CATALINA HERNÁNDEZ [25%]; HERNÁN GUZMÁN [25%]; INTERNET [1 Auxilio de internet]; OSCAR TORRES [25%] | 8h |  | 138,000 | 138,000 |  | No aceptable | 88% | 88% |
| 48 | 1.5 | Reserva de contingencia | milestone | 0d | 2021-04-05 A | 2021-04-05 A |  | 100% |  | 2021-04-05 | 2021-04-05 | 0d |  |  |  |  |  | 13,000,000 | 13,000,000 | 13,000,000 | No aceptable | 88% | 88% |
